# Anexo 1 Cronograma Proyecto 17012017

Schedule from MS Project, 2016-12-19 to 2017-04-14.
Microsoft

## Calendars

- Estándar: Mon-Fri 09:00-13:00, 15:00-19:00; Sat-Sun off.

## Resources

| Resource |
| --- |
| Jennifer Barriga |
| Edwin Pereira |
| Danny Morales |
| José Antonio Villasís |
| Víctor Pacheco |
| Elizabeth Espinosa |
| MDMQ1 |
| MDMQ2 |
| Sylvia Ripalda |
| Abogado |
| Edgar Álvarez |

## Schedule

| ID | WBS | Task | Type | Duration | Start | Finish | Predecessors | Total slack | Free slack | Constraint | Resources | Work | Text1 |
| --- | --- | --- | --- | --- | --- | --- | --- | --- | --- | --- | --- | --- | --- |
| 1 | 1 | **PROYECTO MDMQ** |  | 85d | 2016-12-19 | 2017-04-14 |  | 0d |  |  |  | 4928h |  |
| 2 | 1.1 | **I. Gestión del Proyecto** |  | 84d | 2016-12-19 | 2017-04-13 |  | 0d |  |  |  | 920h |  |
| 3 | 1.1.1 | **Plan del Proyecto** |  | 6d | 2016-12-19 | 2016-12-26 |  | 0d |  |  | Edgar Álvarez | 96h |  |
| 4 | 1.1.1.1 | Elaboración del Plan del Proyecto |  | 5d | 2016-12-19 | 2016-12-23 |  | 0d |  |  | Jennifer Barriga | 40h |  |
| 5 | 1.1.1.2 | Entregable: Cronograma indicando actividades e hitos a cumplir, responsables, fechas, recursos y riesgos | milestone | 0d | 2016-12-23 | 2016-12-23 | 4 | 0d |  |  |  |  | 11 |
| 6 | 1.1.1.3 | Entregable: Estructura de desglose de trabajo | milestone | 0d | 2016-12-23 | 2016-12-23 | 4 | 0d |  |  |  |  | 12 |
| 7 | 1.1.1.4 | Entregable: Metodología de trabajo y formatos a utilizar | milestone | 0d | 2016-12-23 | 2016-12-23 | 4 | 0d |  |  |  |  | 13 |
| 8 | 1.1.1.5 | Reunión de validación del Plan del Proyecto |  | 1d | 2016-12-26 | 2016-12-26 | 5, 6, 7 | 0d |  |  | Edgar Álvarez | 8h |  |
| 9 | 1.1.2 | **Inicio del Proyecto** |  | 12d | 2016-12-27 | 2017-01-11 |  | 0d |  |  | Edgar Álvarez | 120h |  |
| 10 | 1.1.2.1 | Elaboración del Acta de constitución del proyecto |  | 1d | 2016-12-27 | 2016-12-27 | 8 | 0d |  |  | Jennifer Barriga | 8h |  |
| 11 | 1.1.2.2 | Producto: Acta de constitución del proyecto | milestone | 0d | 2016-12-27 | 2016-12-27 | 10 | 0d |  |  |  |  |  |
| 12 | 1.1.2.3 | Preparación del material para el Taller de Lanzamiento del Proyecto (Kick-off) |  | 1d | 2016-12-28 | 2016-12-28 | 11 | 77d |  |  | José Antonio Villasís | 8h |  |
| 13 | 1.1.2.4 | Taller de Lanzamiento del Proyecto (Kick-off) |  | 1d | 2017-01-11 | 2017-01-11 |  | 14d | 0d | start no earlier than 2017-01-11 | Edgar Álvarez | 8h |  |
| 14 | 1.1.2.5 | Entregable: Acta de Asistencias de lanzamiento del proyecto con Stakeholders (Kickoff) | milestone | 0d | 2017-01-11 | 2017-01-11 | 13 | 63d | 0d |  |  |  | 15 |
| 15 | 1.1.3 | **Capacitación y Transferencia de Conocimiento** |  | 17d | 2016-12-27 | 2017-01-18 |  | 62d |  |  | Edgar Álvarez | 224h |  |
| 16 | 1.1.3.1 | Elaboración del Plan de Capacitación y Transferencia de Conocimiento |  | 2d | 2016-12-27 | 2016-12-28 | 8 | 73d | 0d |  | José Antonio Villasís | 16h |  |
| 17 | 1.1.3.2 | Entregable: Plan de Capacitación y Transferencia de Conocimiento | milestone | 0d | 2016-12-28 | 2016-12-28 | 16 | 73d | 0d |  |  |  | 14 |
| 18 | 1.1.3.3 | Preparación del material para los Eventos de Capacitación |  | 3d | 2016-12-29 | 2017-01-02 | 17 | 73d | 0d |  | Danny Morales | 24h |  |
| 19 | 1.1.3.4 | Producto: Material para los Eventos de Capacitación | milestone | 0d | 2017-01-02 | 2017-01-02 | 18 | 73d | 0d |  |  |  |  |
| 20 | 1.1.3.5 | Preparación de la logística para los eventos de capacitación |  | 1d | 2017-01-03 | 2017-01-03 | 19, 17 | 73d |  |  | Elizabeth Espinosa | 8h |  |
| 21 | 1.1.3.6 | Evento de Capacitación 1 |  | 1d | 2017-01-12 | 2017-01-12 |  | 59d | 0d | start no earlier than 2017-01-12 | Edgar Álvarez | 8h |  |
| 22 | 1.1.3.7 | Evento de Capacitación 2 |  | 1d | 2017-01-13 | 2017-01-13 | 21 | 59d | 0d |  | Jennifer Barriga | 8h |  |
| 23 | 1.1.3.8 | Evento de Capacitación 3 |  | 1d | 2017-01-16 | 2017-01-16 | 22 | 59d | 0d |  | Danny Morales | 8h |  |
| 24 | 1.1.3.9 | Impresión de Certificados de Capacitación |  | 2d | 2017-01-17 | 2017-01-18 | 21, 22, 23 | 59d | 0d |  | Elizabeth Espinosa | 16h |  |
| 25 | 1.1.3.10 | Entregable: Certificados de Capacitación por cada evento | milestone | 0d | 2017-01-18 | 2017-01-18 | 24 | 59d | 58d |  |  |  | 16 |

| ID | WBS | Task | Type | Duration | Start | Finish | Predecessors | Total slack | Free slack | Resources | Work | Text1 |
| --- | --- | --- | --- | --- | --- | --- | --- | --- | --- | --- | --- | --- |
| 26 | 1.1.4 | **Certificación del Modelo de Prestación de Servicios y Administración por Procesos del MDMQ** |  | 3d | 2017-04-11 | 2017-04-13 | 25 | 1d |  | Edgar Álvarez | 48h |  |
| 27 | 1.1.4.1 | Preparación del material para la certificación |  | 1d | 2017-04-11 | 2017-04-11 | 131, 194 | 1d | 0d | Jennifer Barriga | 8h |  |
| 28 | 1.1.4.2 | Preparación de la logística para la certificación |  | 1d | 2017-04-12 | 2017-04-12 | 27 | 1d | 0d | Elizabeth Espinosa | 8h |  |
| 29 | 1.1.4.3 | Ejecución de la capacitación online para la certificación |  | 1d | 2017-04-13 | 2017-04-13 | 28 | 1d | 0d | Edgar Álvarez | 8h |  |
| 30 | 1.1.4.4 | Producto: Certificados del Modelo de Prestación de S&P | milestone | 0d | 2017-04-13 | 2017-04-13 | 29 | 1d |  |  |  |  |
| 31 | 1.1.5 | **Entrega-recepción Producto 1** |  | 2d | 2017-01-19 | 2017-01-20 |  | 58d |  | Edgar Álvarez | 32h |  |
| 32 | 1.1.5.1 | Preparación entrega Producto 1 |  | 1d | 2017-01-19 | 2017-01-19 | 5, 6, 7, 14, 17, 25 | 58d | 0d | Jennifer Barriga | 8h |  |
| 33 | 1.1.5.2 | Reunión de revisión previa de entregables Producto 1 |  | 1d | 2017-01-20 | 2017-01-20 | 32 | 58d | 0d | Edgar Álvarez | 8h |  |
| 34 | 1.1.5.3 | Producto: Acta de entrega-recepción Producto 1 - Gestión del Proyecto | milestone | 0d | 2017-01-20 | 2017-01-20 | 33 | 58d |  |  |  |  |
| 35 | 1.1.6 | **Seguimiento del Proyecto** |  | 46d | 2017-01-23 | 2017-03-27 |  | 14d |  | Edgar Álvarez | 400h |  |
| 36 | 1.1.6.1 | Reunión 1 de Seguimiento del Proyecto |  | 1d | 2017-01-23 | 2017-01-23 | 13SS+8d | 14d | 0d | Jennifer Barriga | 8h |  |
| 37 | 1.1.6.2 | Reunión 2 de Seguimiento del Proyecto |  | 1d | 2017-02-13 | 2017-02-13 | 36SS+15d | 14d | 0d | Jennifer Barriga | 8h |  |
| 38 | 1.1.6.3 | Reunión 3 de Seguimiento del Proyecto |  | 1d | 2017-03-06 | 2017-03-06 | 37SS+15d | 14d | 0d | Jennifer Barriga | 8h |  |
| 39 | 1.1.6.4 | Reunión 4 de Seguimiento del Proyecto |  | 1d | 2017-03-27 | 2017-03-27 | 38SS+15d | 14d |  | Jennifer Barriga | 8h |  |
| 40 | 1.2 | **II. Establecimiento del modelo de Prestación de Servicios y Administración por Procesos** |  | 11d | 2017-01-25 | 2017-02-08 |  | 0d |  | Jennifer Barriga | 440h |  |
| 41 | 1.2.1 | **Identificación del Portafolio de Servicios** |  | 5d | 2017-01-25 | 2017-01-31 |  | 1d |  | José Antonio Villasís | 80h |  |
| 42 | 1.2.1.1 | Levantamiento, identificación y análisis de Servicios |  | 5d | 2017-01-25 | 2017-01-31 | 79 | 1d | 0d | Víctor Pacheco | 40h |  |
| 43 | 1.2.1.2 | Entregable: Matriz de Levantamiento Inicial de Servicios | milestone | 0d | 2017-01-31 | 2017-01-31 | 42 | 1d | 0d |  |  | 22 |
| 44 | 1.2.1.3 | Entregable: Portafolio de Servicios | milestone | 0d | 2017-01-31 | 2017-01-31 | 43 | 1d | 0d |  |  | 21 |
| 45 | 1.2.2 | **Jerarquización de Servicios** |  | 1d | 2017-02-01 | 2017-02-01 |  | 48d |  | José Antonio Villasís | 16h |  |
| 46 | 1.2.2.1 | Elaboración de la Jerarquía de Servicios en WBS |  | 1d | 2017-02-01 | 2017-02-01 | 43 | 48d | 0d | Víctor Pacheco | 8h |  |
| 47 | 1.2.2.2 | Entregable: Jerarquización de Servicios en WBS | milestone | 0d | 2017-02-01 | 2017-02-01 | 46 | 48d | 0d |  |  | 23 |
| 48 | 1.2.3 | **Reunión de validación** |  | 2d | 2017-02-02 | 2017-02-03 |  | 50d |  | José Antonio Villasís | 32h |  |
| 49 | 1.2.3.1 | Preparación de la logística |  | 1d | 2017-02-02 | 2017-02-02 | 43, 44, 47 | 50d | 0d | Elizabeth Espinosa | 8h |  |
| 50 | 1.2.3.2 | Reunión de validación del Portafolio de Servicios |  | 1d | 2017-02-03 | 2017-02-03 | 49 | 50d |  | José Antonio Villasís | 8h |  |

| ID | WBS | Task | Type | Duration | Start | Finish | Predecessors | Total slack | Free slack | Resources | Work | Text1 |
| --- | --- | --- | --- | --- | --- | --- | --- | --- | --- | --- | --- | --- |
| 51 | 1.2.4 | **Identificación del Catálogo de Procesos** |  | 5d | 2017-01-25 | 2017-01-31 |  | 0d |  | Danny Morales | 80h |  |
| 52 | 1.2.4.1 | Talleres de levantamiento e identificación de Procesos |  | 5d | 2017-01-25 | 2017-01-31 | 78 | 0d |  | Sylvia Ripalda | 40h |  |
| 53 | 1.2.4.2 | Entregable: Inventario de Procesos | milestone | 0d | 2017-01-31 | 2017-01-31 | 52 | 49d | 2d |  |  | 24 |
| 54 | 1.2.4.3 | Entregable: Catálogo de Procesos | milestone | 0d | 2017-01-31 | 2017-01-31 | 52 | 0d |  |  |  | 25 |
| 55 | 1.2.5 | **Construcción de la Cadena de Valor** |  | 1d | 2017-02-01 | 2017-02-01 |  | 47d |  | Danny Morales | 16h |  |
| 56 | 1.2.5.1 | Elaboración de la Cadena de Valor |  | 1d | 2017-02-01 | 2017-02-01 | 54 | 47d | 0d | Víctor Pacheco | 8h |  |
| 57 | 1.2.5.2 | Entregable: Cadena de Valor | milestone | 0d | 2017-02-01 | 2017-02-01 | 56 | 47d | 0d |  |  | 26 |
| 58 | 1.2.6 | **Mapa de Procesos** |  | 2d | 2017-02-02 | 2017-02-03 |  | 47d |  | Danny Morales | 32h |  |
| 59 | 1.2.6.1 | Elaboración del Mapa de Procesos |  | 1d | 2017-02-02 | 2017-02-02 | 57 | 47d | 0d | Víctor Pacheco | 8h |  |
| 60 | 1.2.6.2 | Entregable: Mapa de Procesos | milestone | 0d | 2017-02-02 | 2017-02-02 | 59 | 47d | 0d |  |  | 27 |
| 61 | 1.2.6.3 | Reunión de validación del Catálogo de Procesos |  | 1d | 2017-02-03 | 2017-02-03 | 53, 54, 57, 60 | 50d |  | Víctor Pacheco | 8h |  |
| 62 | 1.2.7 | **Modelo de prestación de Servicios y Procesos** |  | 2d | 2017-02-01 | 2017-02-02 |  | 45d |  | Danny Morales | 32h |  |
| 63 | 1.2.7.1 | Elaboración del Modelo de prestación de Servicios y Procesos |  | 2d | 2017-02-01 | 2017-02-02 | 54, 44 | 45d | 0d | Víctor Pacheco | 16h |  |
| 64 | 1.2.7.2 | Entregable: Modelo de Prestación de Servicios y Administración por Procesos | milestone | 0d | 2017-02-02 | 2017-02-02 | 63 | 45d | 0d |  |  | 28 |
| 65 | 1.2.7.3 | Entregable: Matriz de Relación Servicio –Proceso de los servicios priorizados | milestone | 0d | 2017-02-02 | 2017-02-02 | 63 | 45d | 0d |  |  | 29 |
| 66 | 1.2.8 | **Reunión de validación** |  | 2d | 2017-02-03 | 2017-02-06 |  | 45d |  | Danny Morales | 32h |  |
| 67 | 1.2.8.1 | Preparación de la logística |  | 1d | 2017-02-03 | 2017-02-03 | 65, 64 | 45d | 0d | Elizabeth Espinosa | 8h |  |
| 68 | 1.2.8.2 | Reunión de validación del Modelo de prestación de Servicios y Procesos |  | 1d | 2017-02-06 | 2017-02-06 | 67 | 45d | 0d | Danny Morales | 8h |  |
| 69 | 1.2.9 | **Entrega-recepción Producto 2** |  | 2d | 2017-02-07 | 2017-02-08 |  | 45d |  | Edgar Álvarez | 32h |  |
| 70 | 1.2.9.1 | Preparación entrega Producto 2 |  | 1d | 2017-02-07 | 2017-02-07 | 43, 44, 47, 53, 54, 57, 60, 64, 68 | 45d | 0d | Jennifer Barriga | 8h |  |
| 71 | 1.2.9.2 | Reunión de revisión previa de entregables Producto 2 |  | 1d | 2017-02-08 | 2017-02-08 | 70 | 45d | 0d | Edgar Álvarez | 8h |  |
| 72 | 1.2.9.3 | Producto: Acta de entrega-recepción Producto 2 - Establecimiento del modelo de Prestación de Servicios y Administración por Procesos | milestone | 0d | 2017-02-08 | 2017-02-08 | 71 | 45d |  |  |  |  |
| 73 | 1.3 | **III. Definición de instrumentos normativos** |  | 24d | 2016-12-28 | 2017-01-30 |  | 0d |  | Danny Morales | 576h |  |
| 74 | 1.3.1 | **Construcción de la Normá Técnica de Servicios y Procesos** |  | 10d | 2016-12-28 | 2017-01-10 |  | 0d |  | Danny Morales | 160h |  |
| 75 | 1.3.1.1 | Elaboración de la Norma Técnica |  | 10d | 2016-12-28 | 2017-01-10 | 11 | 0d |  | Danny Morales | 80h |  |
| 76 | 1.3.1.2 | Entregable: Norma Técnica | milestone | 0d | 2017-01-10 | 2017-01-10 | 75 | 0d |  |  |  | 31 |

| ID | WBS | Task | Type | Duration | Start | Finish | Predecessors | Total slack | Free slack | Resources | Work | Text1 |
| --- | --- | --- | --- | --- | --- | --- | --- | --- | --- | --- | --- | --- |
| 77 | 1.3.2 | **Desarrollo de la Metodología de Servicios y Procesos** |  | 10d | 2017-01-11 | 2017-01-24 |  | 0d |  | Danny Morales | 160h |  |
| 78 | 1.3.2.1 | Elaboración de la Metodología |  | 10d | 2017-01-11 | 2017-01-24 | 76 | 0d |  | Sylvia Ripalda | 80h |  |
| 79 | 1.3.2.2 | Entregable: Metodología | milestone | 0d | 2017-01-24 | 2017-01-24 | 78 | 1d | 0d |  |  | 32 |
| 80 | 1.3.3 | **Cuadernos de Trabajo** |  | 2d | 2017-01-25 | 2017-01-26 |  | 52d |  | Jennifer Barriga | 32h |  |
| 81 | 1.3.3.1 | Elaboración de los Cuadernos de Trabajo |  | 2d | 2017-01-25 | 2017-01-26 | 79 | 52d | 0d | Elizabeth Espinosa | 16h |  |
| 82 | 1.3.3.2 | Entregable: Propuesta de Cuadernos de Trabajo | milestone | 0d | 2017-01-26 | 2017-01-26 | 81 | 52d | 0d |  |  | 33 |
| 83 | 1.3.4 | **Entrega-recepción Producto 3** |  | 2d | 2017-01-27 | 2017-01-30 |  | 52d |  | Edgar Álvarez | 32h |  |
| 84 | 1.3.4.1 | Preparación entrega Producto 3 |  | 1d | 2017-01-27 | 2017-01-27 | 76, 79, 82 | 52d | 0d | Jennifer Barriga | 8h |  |
| 85 | 1.3.4.2 | Reunión de revisión previa de entregables Producto 3 |  | 1d | 2017-01-30 | 2017-01-30 | 84 | 52d | 0d | Edgar Álvarez | 8h |  |
| 86 | 1.3.4.3 | Producto: Acta de entrega-recepción Producto 3 - Definición de instrumentos normativos | milestone | 0d | 2017-01-30 | 2017-01-30 | 85 | 52d |  |  |  |  |
| 87 | 1.4 | **IV. Optimización y estandarización de Procesos Adjetivos** |  | 51d | 2017-02-01 | 2017-04-12 |  | 0d |  | Danny Morales | 1432h |  |
| 88 | 1.4.1 | **Identificación del Catálogo de Procesos adjetivos** |  | 3d | 2017-02-01 | 2017-02-03 |  | 0d |  | Danny Morales | 48h |  |
| 89 | 1.4.1.1 | Elaboración del Catálogo de Procesos Adjetivos |  | 3d | 2017-02-01 | 2017-02-03 | 54 | 0d |  | Sylvia Ripalda | 24h |  |
| 90 | 1.4.1.2 | Entregable: Catálogo de Procesos Adjetivos | milestone | 0d | 2017-02-03 | 2017-02-03 | 89 | 0d |  |  |  | 41 |
| 91 | 1.4.2 | **Priorización de Procesos Adjetivos** |  | 4d | 2017-02-06 | 2017-02-09 |  | 0d |  | Danny Morales | 64h |  |
| 92 | 1.4.2.1 | Elaboración de la Matriz de Priorización de Procesos Adjetivos |  | 4d | 2017-02-06 | 2017-02-09 | 90 | 0d |  | Sylvia Ripalda | 32h |  |
| 93 | 1.4.2.2 | Entregable: Matriz de Priorización de (4) cuatro Procesos Adjetivos | milestone | 0d | 2017-02-09 | 2017-02-09 | 92 | 0d |  |  |  | 42 |
| 94 | 1.4.3 | **Reunión de validación** |  | 3d | 2017-02-10 | 2017-02-14 |  | 0d |  | Danny Morales | 48h |  |
| 95 | 1.4.3.1 | Preparación de la logística |  | 1d | 2017-02-10 | 2017-02-10 | 93, 90 | 0d |  | Elizabeth Espinosa | 8h |  |
| 96 | 1.4.3.2 | Reunión de validación de Procesos Adjetivos priorizados |  | 2d | 2017-02-13 | 2017-02-14 | 95 | 0d |  | Sylvia Ripalda | 16h |  |
| 97 | 1.4.4 | **Levantamiento y estandarización de Procesos Adjetivos priorizados** |  | 9d | 2017-02-15 | 2017-02-27 |  | 0d |  | Danny Morales | 144h |  |
| 98 | 1.4.4.1 | Elaboración del Cronograma de levantamiento |  | 1d | 2017-02-15 | 2017-02-15 | 96 | 0d |  | Sylvia Ripalda | 8h |  |
| 99 | 1.4.4.2 | Entregable: Cronograma de levantamiento de procesos adjetivos priorizados de la situación actual | milestone | 0d | 2017-02-15 | 2017-02-15 | 98 | 0d |  |  |  | 43 |
| 100 | 1.4.4.3 | Caracterización de Procesos Adjetivos priorizados |  | 4d | 2017-02-16 | 2017-02-21 | 99 | 7d | 0d | Sylvia Ripalda | 32h |  |
| 101 | 1.4.4.4 | Entregable: Caracterización de procesos Adjetivos priorizados | milestone | 0d | 2017-02-21 | 2017-02-21 | 100 | 7d | 0d |  |  | 44 |
| 102 | 1.4.4.5 | Modelamiento de los Procesos Adjetivos priorizados |  | 4d | 2017-02-22 | 2017-02-27 | 101 | 7d | 0d | Sylvia Ripalda | 32h |  |
| 103 | 1.4.4.6 | Entregable: Diagramas de Flujo de procesos Adjetivos priorizados en notación BPMN 2.0 | milestone | 0d | 2017-02-27 | 2017-02-27 | 102 | 7d | 0d |  |  | 45 |

| ID | WBS | Task | Type | Duration | Start | Finish | Predecessors | Total slack | Free slack | Resources | Work | Text1 |
| --- | --- | --- | --- | --- | --- | --- | --- | --- | --- | --- | --- | --- |
| 104 | 1.4.5 | **Reunión de aprobación** |  | 3d | 2017-02-28 | 2017-03-02 |  | 27d |  | Danny Morales | 48h |  |
| 105 | 1.4.5.1 | Preparación de la logística |  | 1d | 2017-02-28 | 2017-02-28 | 101, 103 | 27d | 0d | Elizabeth Espinosa | 8h |  |
| 106 | 1.4.5.2 | Reunión de aprobación del levantamiento y caracterización de procesos adjetivos |  | 2d | 2017-03-01 | 2017-03-02 | 105 | 27d | 0d | Danny Morales | 16h |  |
| 107 | 1.4.5.3 | Entregable: Actas de aprobación del levantamiento y caracterización de Procesos Adjetivos | milestone | 0d | 2017-03-02 | 2017-03-02 | 106 | 27d |  |  |  | 46 |
| 108 | 1.4.6 | **Análisis del Marco Legal** |  | 15d | 2017-02-16 | 2017-03-08 |  | 0d |  | Abogado | 240h |  |
| 109 | 1.4.6.1 | Elaboración del Informe de Análisis Legal |  | 15d | 2017-02-16 | 2017-03-08 | 99 | 0d |  | Abogado | 120h |  |
| 110 | 1.4.6.2 | Entregable: Informe de Análisis Legal | milestone | 0d | 2017-03-08 | 2017-03-08 | 109 | 0d |  |  |  | 471 |
| 111 | 1.4.7 | **Análisis Tecnológico** |  | 2d | 2017-02-16 | 2017-02-17 |  | 13d |  | José Antonio Villasís | 32h |  |
| 112 | 1.4.7.1 | Reuniones de levantamiento de información de TI |  | 2d | 2017-02-16 | 2017-02-17 | 99 | 13d | 0d | José Antonio Villasís | 16h |  |
| 113 | 1.4.7.2 | Entregable: Informe de Análisis Tecnológico | milestone | 0d | 2017-02-17 | 2017-02-17 | 112 | 13d |  |  |  | 472 |
| 114 | 1.4.8 | **Identificación de Oportunidades de Mejora** |  | 2d | 2017-03-09 | 2017-03-10 |  | 0d |  | Danny Morales | 32h |  |
| 115 | 1.4.8.1 | Elaboración de la Matriz de Oportunidades de Mejora |  | 2d | 2017-03-09 | 2017-03-10 | 101, 103, 110, 113 | 0d |  | Sylvia Ripalda | 16h |  |
| 116 | 1.4.8.2 | Entregable: Matriz de Oportunidades de Mejora Identificadas | milestone | 0d | 2017-03-10 | 2017-03-10 | 115 | 0d |  |  |  | 48 |
| 117 | 1.4.9 | **Mejoramiento de Procesos adjetivos** |  | 8d | 2017-03-13 | 2017-03-22 |  | 0d |  | Danny Morales | 128h |  |
| 118 | 1.4.9.1 | Modelamiento de flujos de procesos adjetivos priorizados TO BE a corto plazo |  | 4d | 2017-03-13 | 2017-03-16 | 116 | 0d |  | Sylvia Ripalda | 32h |  |
| 119 | 1.4.9.2 | Entregable: Diagrama de Flujo de procesos adjetivos priorizados TO BE a corto plazo en notación BPMN 2.0 | milestone | 0d | 2017-03-16 | 2017-03-16 | 118 | 0d |  |  |  | 49 |
| 120 | 1.4.9.3 | Elaboración del Manual de Procesos TO BE a corto plazo |  | 4d | 2017-03-17 | 2017-03-22 | 119 | 0d |  | Sylvia Ripalda | 32h |  |
| 121 | 1.4.9.4 | Entregable: Manual de Procesos TO BE a corto plazo | milestone | 0d | 2017-03-22 | 2017-03-22 | 120 | 0d |  |  |  | 411 |
| 122 | 1.4.10 | **Propuesta de Automatización** |  | 12d | 2017-03-23 | 2017-04-07 |  | 0d |  | Danny Morales | 192h |  |
| 123 | 1.4.10.1 | Modelamiento de flujos de procesos adjetivos priorizados TO BE automatizables |  | 4d | 2017-03-23 | 2017-03-28 | 121 | 0d |  | Sylvia Ripalda | 32h |  |
| 124 | 1.4.10.2 | Entregable: Diagrama de Flujo de procesos adjetivos priorizados TO BE automatizable en notación BPMN 2.0 | milestone | 0d | 2017-03-28 | 2017-03-28 | 123 | 0d |  |  |  | 410 |
| 125 | 1.4.10.3 | Producto: Reglas de Negocio | milestone | 0d | 2017-03-28 | 2017-03-28 | 123 | 20d |  |  |  |  |
| 126 | 1.4.10.4 | Elaboración de Requerimientos Funcionales y Formularios (Prototipos) |  | 8d | 2017-03-29 | 2017-04-07 | 124 | 0d |  | Sylvia Ripalda | 64h |  |
| 127 | 1.4.10.5 | Producto: Requerimientos Funcionales y Formularios | milestone | 0d | 2017-04-07 | 2017-04-07 | 126 | 12d |  |  |  |  |
| 128 | 1.4.10.6 | Producto: Bases de datos a requerirse | milestone | 0d | 2017-04-07 | 2017-04-07 | 126 | 12d |  |  |  |  |
| 129 | 1.4.10.7 | Producto: Matriz de interoperabilidad y conexiones tecnológicas | milestone | 0d | 2017-04-07 | 2017-04-07 | 126 | 12d |  |  |  |  |
| 130 | 1.4.10.8 | Entregable: Propuesta de Automatización | milestone | 0d | 2017-04-07 | 2017-04-07 | 126 | 0d |  |  |  | 412 |

| ID | WBS | Task | Type | Duration | Start | Finish | Predecessors | Total slack | Free slack | Resources | Work | Text1 |
| --- | --- | --- | --- | --- | --- | --- | --- | --- | --- | --- | --- | --- |
| 131 | 1.4.11 | **Plan de Implementación** |  | 1d | 2017-04-10 | 2017-04-10 |  | 0d |  | Danny Morales | 16h |  |
| 132 | 1.4.11.1 | Elaboración del Plan de Implementación y Hoja de ruta |  | 1d | 2017-04-10 | 2017-04-10 | 130 | 0d |  | Sylvia Ripalda | 8h |  |
| 133 | 1.4.11.2 | Entregable: Plan de Implementación | milestone | 0d | 2017-04-10 | 2017-04-10 | 132 | 0d |  |  |  | 413 |
| 134 | 1.4.12 | **Reuniones** |  | 0d | 2017-04-10 | 2017-04-10 |  | 0d |  |  |  |  |
| 135 | 1.4.12.1 | Entregable: Actas de asistencia a reuniones | milestone | 0d | 2017-04-10 | 2017-04-10 | 133 | 0d |  |  |  | 4141 |
| 136 | 1.4.12.2 | Entregable: Registros de asistencia a reuniones | milestone | 0d | 2017-04-10 | 2017-04-10 | 133 | 0d |  |  |  | 4142 |
| 137 | 1.4.13 | **Entrega-recepción Producto 4** |  | 2d | 2017-04-11 | 2017-04-12 |  | 0d |  | Edgar Álvarez | 32h |  |
| 138 | 1.4.13.1 | Preparación entrega Producto 4 |  | 1d | 2017-04-11 | 2017-04-11 | 90, 93, 99, 101, 103, 110, 113, 116, 119, 121, 124, 130, 133, 135, 136, 107 | 0d |  | Jennifer Barriga | 8h |  |
| 139 | 1.4.13.2 | Reunión de revisión previa de entregables Producto 4 |  | 1d | 2017-04-12 | 2017-04-12 | 138 | 0d |  | Edgar Álvarez | 8h |  |
| 140 | 1.4.13.3 | Producto: Acta de entrega-recepción Producto 4 - Optimización y estandarización de procesos adjetivos | milestone | 0d | 2017-04-12 | 2017-04-12 | 139 | 0d |  |  |  |  |
| 141 | 1.5 | **V. Mejoramiento de Servicios** |  | 49d | 2017-02-01 | 2017-04-10 |  | 1d |  | José Antonio Villasís | 1480h |  |
| 142 | 1.5.1 | **Priorización y evaluación de los componentes de los servicios** |  | 2d | 2017-02-01 | 2017-02-02 |  | 1d |  | José Antonio Villasís | 32h |  |
| 143 | 1.5.1.1 | Elaboración de la Matriz de Priorización de Servicios |  | 2d | 2017-02-01 | 2017-02-02 | 44 | 1d | 0d | Víctor Pacheco | 16h |  |
| 144 | 1.5.1.2 | Entregable: Matriz de Priorización de (3) tres servicios municipales | milestone | 0d | 2017-02-02 | 2017-02-02 | 143 | 1d | 0d |  |  | 51 |
| 145 | 1.5.1.3 | Entregable: Cronograma de levantamiento de servicios de la situación actual | milestone | 0d | 2017-02-02 | 2017-02-02 | 144 | 1d | 0d |  |  | 52 |
| 146 | 1.5.2 | **Reunión de validación** |  | 2d | 2017-02-03 | 2017-02-06 |  | 49d |  | José Antonio Villasís | 32h |  |
| 147 | 1.5.2.1 | Preparación de la logística |  | 1d | 2017-02-03 | 2017-02-03 | 145 | 49d | 0d | Elizabeth Espinosa | 8h |  |
| 148 | 1.5.2.2 | Reunión de validación de servicios priorizados |  | 1d | 2017-02-06 | 2017-02-06 | 147 | 49d |  | Víctor Pacheco | 8h |  |
| 149 | 1.5.3 | **Entendimiento de los Servicios** |  | 11d | 2017-02-03 | 2017-02-17 |  | 1d |  | José Antonio Villasís | 176h |  |
| 150 | 1.5.3.1 | Grupo de Enfoque/Encuestas online del Servicio 1 |  | 1d | 2017-02-03 | 2017-02-03 | 145 | 1d | 0d | Jennifer Barriga | 8h |  |
| 151 | 1.5.3.2 | Grupo de Enfoque/Encuestas online del Servicio 2 |  | 1d | 2017-02-06 | 2017-02-06 | 150 | 1d | 0d | Jennifer Barriga | 8h |  |
| 152 | 1.5.3.3 | Grupo de Enfoque/Encuestas online del Servicio 3 |  | 1d | 2017-02-07 | 2017-02-07 | 151 | 1d | 0d | Jennifer Barriga | 8h |  |
| 153 | 1.5.3.4 | Elaboración de Informes de evaluación externa e interna de los servicios |  | 5d | 2017-02-08 | 2017-02-14 | 150, 151, 152 | 1d | 0d | Jennifer Barriga | 40h |  |
| 154 | 1.5.3.5 | Entregable: Informe de Evaluación externa del servicio AS IS | milestone | 0d | 2017-02-14 | 2017-02-14 | 153 | 1d | 0d |  |  | 531 |
| 155 | 1.5.3.6 | Entregable: Informe de Evaluación interna del servicio AS IS | milestone | 0d | 2017-02-14 | 2017-02-14 | 153 | 1d | 0d |  |  | 532 |
| 156 | 1.5.3.7 | Modelamiento de los planos de los servicios priorizados AS IS |  | 3d | 2017-02-15 | 2017-02-17 | 154, 155 | 1d | 0d | Víctor Pacheco | 24h |  |
| 157 | 1.5.3.8 | Entregable: Planos de Servicios priorizados AS IS en notación BPMN 2.0 | milestone | 0d | 2017-02-17 | 2017-02-17 | 156 | 1d | 0d |  |  | 54 |
| 158 | 1.5.3.9 | Entregable: Acta de aprobación del levantamiento de servicios | milestone | 0d | 2017-02-17 | 2017-02-17 | 157, 156 | 1d | 0d |  |  | 57 |

Notes:
- 150: En la metodología no se hace referencia a los Grupos de Enfoque

| ID | WBS | Task | Type | Duration | Start | Finish | Predecessors | Total slack | Free slack | Resources | Work | Text1 |
| --- | --- | --- | --- | --- | --- | --- | --- | --- | --- | --- | --- | --- |
| 159 | 1.5.4 | **Levantamiento de procesos asociados a servicios priorizados** |  | 6d | 2017-02-20 | 2017-02-27 |  | 1d |  | José Antonio Villasís | 96h |  |
| 160 | 1.5.4.1 | Caracterización de Procesos asociados a servicios priorizados |  | 3d | 2017-02-20 | 2017-02-22 | 158 | 1d | 0d | Víctor Pacheco | 24h |  |
| 161 | 1.5.4.2 | Entregable: Caracterización de procesos asociados a servicios priorizados | milestone | 0d | 2017-02-22 | 2017-02-22 | 160 | 1d | 0d |  |  | 55 |
| 162 | 1.5.4.3 | Modelamiento de los procesos asociados a servicios priorizados |  | 3d | 2017-02-23 | 2017-02-27 | 161 | 1d | 0d | Víctor Pacheco | 24h |  |
| 163 | 1.5.4.4 | Entregable: Diagramas de Flujo de procesos asociados a servicios priorizados en notación BPMN 2.0 | milestone | 0d | 2017-02-27 | 2017-02-27 | 162 | 1d | 0d |  |  | 56 |
| 164 | 1.5.4.5 | Entregable: Actas de aprobación de caracterización de procesos asociados a los servicios priorizados | milestone | 0d | 2017-02-27 | 2017-02-27 | 163 | 29d | 28d |  |  | 57 |
| 165 | 1.5.5 | **Análisis del Marco Legal** |  | 15d | 2017-02-03 | 2017-02-23 |  | 31d |  | Abogado | 240h |  |
| 166 | 1.5.5.1 | Elaboración del Informe de Análisis Legal |  | 15d | 2017-02-03 | 2017-02-23 | 145 | 31d | 0d | Abogado | 120h |  |
| 167 | 1.5.5.2 | Entregable: Informe de Análisis Legal | milestone | 0d | 2017-02-23 | 2017-02-23 | 166 | 31d | 30d |  |  | 581 |
| 168 | 1.5.6 | **Análisis Tecnológico** |  | 2d | 2017-02-03 | 2017-02-06 |  | 44d |  | José Antonio Villasís | 32h |  |
| 169 | 1.5.6.1 | Reuniones de levantamiento de información de TI |  | 2d | 2017-02-03 | 2017-02-06 | 145 | 44d | 0d | José Antonio Villasís | 16h |  |
| 170 | 1.5.6.2 | Entregable: Informe de Análisis Tecnológico | milestone | 0d | 2017-02-06 | 2017-02-06 | 169 | 44d | 43d |  |  | 582 |
| 171 | 1.5.7 | **Identificación de Oportunidades de Mejora** |  | 2d | 2017-02-28 | 2017-03-01 |  | 1d |  | José Antonio Villasís | 32h |  |
| 172 | 1.5.7.1 | Elaboración de la Matriz de Oportunidades de Mejora |  | 2d | 2017-02-28 | 2017-03-01 | 157, 154, 155, 163 | 1d | 0d | Víctor Pacheco | 16h |  |
| 173 | 1.5.7.2 | Entregable: Matriz de Oportunidades de Mejora Identificadas | milestone | 0d | 2017-03-01 | 2017-03-01 | 172 | 1d | 0d |  |  | 59 |
| 174 | 1.5.8 | **Plan de Mejora de Servicios priorizados** |  | 1d | 2017-03-02 | 2017-03-02 |  | 1d |  | José Antonio Villasís | 16h |  |
| 175 | 1.5.8.1 | Elaboración del Plan de Mejora de servicios priorizados |  | 1d | 2017-03-02 | 2017-03-02 | 173 | 1d | 0d | Víctor Pacheco | 8h |  |
| 176 | 1.5.8.2 | Entregable: Plan de Mejora de servicios priorizados | milestone | 0d | 2017-03-02 | 2017-03-02 | 175 | 1d | 0d |  |  | 510 |
| 177 | 1.5.9 | **Planos de Servicios priorizados TO BE** |  | 3d | 2017-03-03 | 2017-03-07 |  | 1d |  | José Antonio Villasís | 48h |  |
| 178 | 1.5.9.1 | Modelamiento de los planos de los servicios priorizados TO BE |  | 3d | 2017-03-03 | 2017-03-07 | 176 | 1d | 0d | Víctor Pacheco | 24h |  |
| 179 | 1.5.9.2 | Entregable: Planos de Servicios priorizados TO BE en notación BPMN 2.0 | milestone | 0d | 2017-03-07 | 2017-03-07 | 178 | 1d | 0d |  |  | 511 |
| 180 | 1.5.10 | **Mejoramiento de los procesos asociados a los servicios priorizados** |  | 9d | 2017-03-08 | 2017-03-20 |  | 1d |  | José Antonio Villasís | 144h |  |
| 181 | 1.5.10.1 | Modelamiento de flujos de procesos asociados a los servicios priorizados TO BE a corto plazo |  | 6d | 2017-03-08 | 2017-03-15 | 179 | 1d | 0d | Víctor Pacheco | 48h |  |
| 182 | 1.5.10.2 | Entregable: Diagrama de Flujo TO BE de procesos asociados a los servicios priorizados a corto plazo en notación BPMN 2.0 | milestone | 0d | 2017-03-15 | 2017-03-15 | 181 | 1d | 0d |  |  | 512 |
| 183 | 1.5.10.3 | Elaboración del Manual de Procesos TO BE a corto plazo |  | 3d | 2017-03-16 | 2017-03-20 | 182 | 1d | 0d | Víctor Pacheco | 24h |  |
| 184 | 1.5.10.4 | Entregable: Manual de Procesos TO BE a corto plazo | milestone | 0d | 2017-03-20 | 2017-03-20 | 183 | 1d | 0d |  |  | 514 |

| ID | WBS | Task | Type | Duration | Start | Finish | Predecessors | Total slack | Free slack | Resources | Work | Text1 |
| --- | --- | --- | --- | --- | --- | --- | --- | --- | --- | --- | --- | --- |
| 185 | 1.5.11 | **Propuesta de Automatización** |  | 12d | 2017-03-21 | 2017-04-05 |  | 1d |  | José Antonio Villasís | 192h |  |
| 186 | 1.5.11.1 | Modelamiento de flujos de procesos asociados a los servicios priorizados TO BE automatizables |  | 6d | 2017-03-21 | 2017-03-28 | 184 | 1d | 0d | Víctor Pacheco | 48h |  |
| 187 | 1.5.11.2 | Entregable: Diagrama de Flujo TO BE de procesos asociados a los servicios priorizados automatizable en notación BPMN 2.0 | milestone | 0d | 2017-03-28 | 2017-03-28 | 186 | 1d | 0d |  |  | 513 |
| 188 | 1.5.11.3 | Producto: Reglas de Negocio | milestone | 0d | 2017-03-28 | 2017-03-28 | 186 | 13d |  |  |  |  |
| 189 | 1.5.11.4 | Elaboración de Requerimientos Funcionales y Formularios (Prototipos) |  | 6d | 2017-03-29 | 2017-04-05 | 187 | 1d | 0d | Víctor Pacheco | 48h |  |
| 190 | 1.5.11.5 | Producto: Requerimientos Funcionales y Formularios | milestone | 0d | 2017-04-05 | 2017-04-05 | 189 | 7d |  |  |  |  |
| 191 | 1.5.11.6 | Producto: Bases de datos a requerirse | milestone | 0d | 2017-04-05 | 2017-04-05 | 189 | 7d |  |  |  |  |
| 192 | 1.5.11.7 | Producto: Matriz de interoperabilidad y conexiones tecnológicas | milestone | 0d | 2017-04-05 | 2017-04-05 | 189 | 7d |  |  |  |  |
| 193 | 1.5.11.8 | Entregable: Propuesta de Automatización de los procesos correspondientes a los servicios priorizados | milestone | 0d | 2017-04-05 | 2017-04-05 | 189 | 1d | 0d |  |  | 515 |
| 194 | 1.5.12 | **Plan de Implementación** |  | 1d | 2017-04-06 | 2017-04-06 |  | 1d |  | José Antonio Villasís | 16h |  |
| 195 | 1.5.12.1 | Elaboración del Plan de Implementación y Hoja de ruta |  | 1d | 2017-04-06 | 2017-04-06 | 193 | 1d | 0d | Víctor Pacheco | 8h |  |
| 196 | 1.5.12.2 | Entregable: Plan de Implementación | milestone | 0d | 2017-04-06 | 2017-04-06 | 195 | 1d | 0d |  |  | 516 |
| 197 | 1.5.13 | **Reuniones** |  | 0d | 2017-04-06 | 2017-04-06 |  | 1d |  |  |  |  |
| 198 | 1.5.13.1 | Entregable: Actas de asistencia a reuniones | milestone | 0d | 2017-04-06 | 2017-04-06 | 196 | 1d | 0d |  |  | 5171 |
| 199 | 1.5.13.2 | Entregable: Registros de asistencia a reuniones | milestone | 0d | 2017-04-06 | 2017-04-06 | 196 | 1d | 0d |  |  | 5172 |
| 200 | 1.5.14 | **Entrega-recepción Producto 5** |  | 2d | 2017-04-07 | 2017-04-10 |  | 1d |  | Edgar Álvarez | 32h |  |
| 201 | 1.5.14.1 | Preparación entrega Producto 5 |  | 1d | 2017-04-07 | 2017-04-07 | 144, 145, 154, 155, 157, 158, 161, 163, 164, 167, 170, 173, 176, 179, 182, 184, 187, 193, 196, 198, 199 | 1d | 0d | Jennifer Barriga | 8h |  |
| 202 | 1.5.14.2 | Reunión de revisión previa de entregables Producto 5 |  | 1d | 2017-04-10 | 2017-04-10 | 201 | 1d | 0d | Edgar Álvarez | 8h |  |
| 203 | 1.5.14.3 | Producto: Acta de entrega-recepción Producto 5 - Mejoramiento de Servicios | milestone | 0d | 2017-04-10 | 2017-04-10 | 202 | 1d | 0d |  |  |  |
| 204 | 1.6 | **VI. Cierre del Proyecto** |  | 4d | 2017-04-11 | 2017-04-14 |  | 0d |  | Edgar Álvarez | 80h |  |
| 205 | 1.6.1 | **Informe final de cierre del Proyecto** |  | 1d | 2017-04-11 | 2017-04-11 |  | 1d |  | Jennifer Barriga | 16h |  |
| 206 | 1.6.1.1 | Elaboración del Informe final de cierre del Proyecto |  | 1d | 2017-04-11 | 2017-04-11 | 203 | 1d | 0d | Jennifer Barriga | 8h |  |
| 207 | 1.6.1.2 | Entregable: Informe final de cierre del proyecto que deberá contemplar resultados y lecciones aprendidas | milestone | 0d | 2017-04-11 | 2017-04-11 | 206 | 1d |  |  |  | 61 |
| 208 | 1.6.2 | **Entrega-recepción definitiva** |  | 2d | 2017-04-13 | 2017-04-14 |  | 0d |  | Edgar Álvarez | 32h |  |
| 209 | 1.6.2.1 | Preparación entrega definitiva |  | 1d | 2017-04-13 | 2017-04-13 | 34, 72, 86, 140, 203, 207 | 0d |  | Jennifer Barriga | 8h |  |
| 210 | 1.6.2.2 | Reunión de entrega-recepción definitiva |  | 1d | 2017-04-14 | 2017-04-14 | 209 | 0d |  | Edgar Álvarez | 8h |  |
| 211 | 1.6.2.3 | Producto: Acta de entrega-recepción definitiva | milestone | 0d | 2017-04-14 | 2017-04-14 | 210 | 0d |  |  |  |  |
